# Billing System Enhancements

Schedule from Primavera P6, 2010-01-04 to 2011-03-01, data date 2010-05-17, costs in CAD, A marks actual dates.
Must finish by 2011-02-01

## Calendars

- Standard 5 Day Workweek: Mon-Fri 08:00-12:00, 13:00-17:00; Sat-Sun off.

## Resources

| Resource | Group | Rate |
| --- | --- | --- |
| Tom Bell | labor | 55.29 |
| Chris Booth | labor | 49.76 |
| Robin Brown | labor | 60.82 |

## Schedule

| ID | WBS | Activity | Type | Duration | Start | Finish | Predecessors | Complete | Remaining | Planned start | Planned finish | Total float | Free float | Resources | Cost | Actual cost |
| --- | --- | --- | --- | --- | --- | --- | --- | --- | --- | --- | --- | --- | --- | --- | --- | --- |
| A1030 |  | Project Kick-Off | milestone | 0d | 2010-01-04 A | 2010-01-04 A |  | 100% |  |  |  |  |  |  |  |  |
|  | DPL | **New Hardware Deployment** |  |  | 2010-01-04 | 2010-04-21 |  |  |  |  |  |  |  |  |  |  |
| A1000 |  | Replace Hardware | resource dependent | 120.88d | 2010-01-04 A | 2010-04-21 A | A1030 | 100% |  | 2010-01-04 | 2010-06-21 |  |  | Tom Bell [960 h] | 53,075.03 | 56,613.37 |
|  | IMPL | **New Software Install** |  |  | 2010-04-28 | 2010-12-20 |  |  |  |  |  |  |  |  |  |  |
| A1010 |  | Install Multi-Media Software |  | 160d | 2010-04-28 A | 2010-12-20 | A1000 | 3% | 155.2d | 2010-04-26 | 2010-12-03 | -21d | 0d | Chris Booth [1280 h] | 63,690.04 | 1,194.19 |
|  | CNV | **Legacy System Convertion** |  |  | 2010-05-26 | 2011-03-01 |  |  |  |  |  |  |  |  |  |  |
| A1020 |  | Convert Legacy Data |  | 200d | 2010-05-26 | 2011-03-01 | A1010 SS+20d |  |  |  |  | -21d | 0d | Chris Booth [1600 h]; Robin Brown [1600 h] | 176,916.78 |  |
| A1040 |  | Project Closure | milestone | 0d | 2011-03-01 | 2011-03-01 | A1020, A1010 |  |  |  |  | -21d | 0d |  |  |  |
